# PRODUCTIE SCHEMA AFBOUW

Schedule from MS Project, 2005-01-10 to 2005-08-10, status date 2003-06-02.
BAM Nelissen Van Egteren

## Calendars

- Standaard: Mon-Fri 08:30-12:30, 13:00-17:00; Sat-Sun off.

## Resources

| Resource |
| --- |
| beg.grond |
| 1e verd |
| 2e verd |
| 3e verd |
| 4e verd |
| 1e verd,vloer |
| 2e verd,vloer |
| 3e verd,vloer |
| 4e verd,vloer |
| dakvloer |

## Schedule

| ID | WBS | Task | Duration | Start | Finish | Predecessors | Total slack | Free slack | Text1 |
| --- | --- | --- | --- | --- | --- | --- | --- | --- | --- |
| 1 | 1 | **PRIMAIRE INSTALLATIES** | 50d | 2005-01-10 | 2005-03-18 |  | 0d |  |  |
| 2 | 1.1 | water+riolering in schachten | 10d | 2005-01-10 | 2005-01-21 |  | 0d |  | st |
| 3 | 1.2 | water+riolering aan plafond | 25d | 2005-01-10 | 2005-02-11 | 2SS | 128d |  | bvo |
| 4 | 1.3 | electrakabels in schachten | 10d | 2005-01-10 | 2005-01-21 |  | 128d | 0d | st |
| 5 | 1.4 | electra kabelgoten aan plafond | 25d | 2005-01-10 | 2005-02-11 | 4SS | 128d |  | bvo |
| 6 | 1.5 | luchtkanalen in schachten | 10d | 2005-01-10 | 2005-01-21 |  | 128d | 0d | st |
| 7 | 1.6 | luchtkanalen aan plafond | 25d | 2005-01-10 | 2005-02-11 | 6SS | 128d |  | bvo |
| 8 | 1.7 | liftschacht montage lift installatie | 50d | 2005-01-10 | 2005-03-18 |  | 103d |  | st |
| 10 | 2 | **INBOUW FASE L 4,3,2,1,0 R 4,3,2,1,0** | 89d | 2005-01-31 | 2005-06-02 |  | 0d |  |  |
| 11 | 2.1 | cementdekvloer linkervleugel | 20d | 2005-01-31 | 2005-02-25 | 2FS+5d | 0d |  | m2 |
| 12 | 2.2 | cementdekvloer rechtervleugel | 20d | 2005-02-28 | 2005-03-25 | 11 | 98d |  | m2 |
| 13 | 2.3 | Gmwanden frame+kozijnen | 50d | 2005-02-14 | 2005-04-25 | 11SS+10d | 0d |  | m1 |
| 14 | 2.4 | gipsplaten eenzijdig aanbrengen | 50d | 2005-02-17 | 2005-04-28 | 13SS+3d | 0d |  | m1 |
| 15 | 2.5 | leidingen in wandspouw | 50d | 2005-02-23 | 2005-05-04 | 14SS+4d | 0d |  | m1 |
| 16 | 2.6 | gipsplaten sluitwand aanbr | 50d | 2005-03-01 | 2005-05-10 | 15SS+4d | 0d |  | m1 |
| 17 | 2.7 | wanden plaatnaden afwerken | 50d | 2005-03-07 | 2005-05-16 | 16SS+4d | 0d |  | m1 |
| 18 | 2.8 | plafonds kabelgoten+bekabeling | 50d | 2005-03-10 | 2005-05-19 | 17SS+3d | 0d |  | bvo |
| 19 | 2.9 | plafonds randlat+regelwerk | 50d | 2005-03-15 | 2005-05-24 | 18SS+3d | 0d |  | bvo |
| 20 | 2.10 | plafond electra+armaturen | 50d | 2005-03-18 | 2005-05-27 | 19SS+3d | 0d |  | bvo |
| 21 | 2.11 | plafond luchtkanalen+roosters | 50d | 2005-03-24 | 2005-06-02 | 20SS+4d | 0d |  | bvo |
| 23 | 3 | **AFWERKINGS FASE L 4,3,2,1,0 R 4,3,2,1,0** | 71d | 2005-03-31 | 2005-07-07 |  | 0d |  |  |
| 24 | 3.1 | plafond platen dichtleggen | 50d | 2005-03-31 | 2005-06-09 | 21SS+5d | 0d |  | bvo |
| 25 | 3.2 | gevelwanden spuitwerk | 50d | 2005-04-06 | 2005-06-15 | 24SS+4d | 0d |  | m2 |
| 26 | 3.3 | binnnenwanden glasvlies+verf | 50d | 2005-04-12 | 2005-06-21 | 25SS+4d | 0d |  | m2 |
| 27 | 3.4 | aftimmeren plinten+vensterbank | 50d | 2005-04-15 | 2005-06-24 | 26SS+3d | 0d |  | bvo |
| 28 | 3.5 | afschilderen kozijnen+plinten | 50d | 2005-04-20 | 2005-06-29 | 27SS+3d | 0d |  | bvo |
| 29 | 3.6 | harde vloerbedekking | 50d | 2005-04-25 | 2005-07-04 | 28SS+3d | 0d |  | m2 |
| 30 | 3.7 | zachte vloerbedekking | 50d | 2005-04-28 | 2005-07-07 | 29SS+3d | 0d |  | m2 |

| ID | WBS | Task | Type | Duration | Start | Finish | Predecessors | Total slack | Free slack | Text1 |
| --- | --- | --- | --- | --- | --- | --- | --- | --- | --- | --- |
| 32 | 4 | **UITRUSTINGSFASE l 4,3,2,1,0 R 4,3,2,1,0** |  | 55d | 2005-05-03 | 2005-07-18 |  | 0d |  |  |
| 33 | 4.1 | vaste inrichting plaatsen |  | 50d | 2005-05-03 | 2005-07-12 | 30SS+3d | 0d |  | bvo |
| 34 | 4.2 | bouwkundige afmontage |  | 50d | 2005-05-04 | 2005-07-13 | 33SS+1d | 0d |  | bvo |
| 35 | 4.3 | electra afmontage |  | 50d | 2005-05-05 | 2005-07-14 | 34SS+1d | 0d |  | bvo |
| 36 | 4.4 | werktuigkundige afmontage |  | 50d | 2005-05-09 | 2005-07-18 | 35SS+2d | 0d |  | bvo |
| 38 | 5 | **AFBOUW KERNGEBIED** |  | 35d | 2005-06-03 | 2005-07-21 |  | 14d |  |  |
| 39 | 5.1 | trappenhuis trappen monteren |  | 10d | 2005-06-03 | 2005-06-16 | 21 | 14d | 0d | ver |
| 40 | 5.2 | trappenhuis afwerking |  | 10d | 2005-06-10 | 2005-06-23 | 39SS+5d | 14d | 0d | ver |
| 41 | 5.3 | toiletten binnenwanden |  | 10d | 2005-06-17 | 2005-06-30 | 40SS+5d | 14d | 0d | st |
| 42 | 5.4 | toiletten tegelwerk |  | 10d | 2005-06-24 | 2005-07-07 | 41SS+5d | 14d | 0d | st |
| 43 | 5.5 | toiletten spuitwerk |  | 10d | 2005-07-01 | 2005-07-14 | 42SS+5d | 14d | 0d | st |
| 44 | 5.6 | toiletten sanitair+kranen |  | 10d | 2005-07-08 | 2005-07-21 | 43SS+5d | 14d |  | st |
| 46 | 6 | **OPLEVERINGSFASE 4,3,2,1,0** |  | 43d | 2005-06-13 | 2005-08-10 |  | 0d |  |  |
| 47 | 6.1 | vooropname door uitvoerder |  | 25d | 2005-06-13 | 2005-07-15 | 36SS+25d | 0d |  | bvo |
| 48 | 6.2 | herstelwerkzaamheden |  | 25d | 2005-06-23 | 2005-07-27 | 47SS+8d | 0d |  | bvo |
| 49 | 6.3 | opnemen voor opleveren |  | 5d | 2005-07-28 | 2005-08-03 | 48 | 0d |  | bvo |
| 50 | 6.4 | narooien opleveringspunten |  | 5d | 2005-08-04 | 2005-08-10 | 49 | 0d |  | bvo |
| 51 | 6.5 | formele oplevering gebouw | milestone | 0d | 2005-08-10 | 2005-08-10 | 50 | 0d |  | bvo |
